# project_office

Schedule from MS Project, 2006-06-01 to 2006-12-27.

## Calendars

- Standard: Mon-Fri 08:00-12:00, 13:00-17:00; Sat-Sun off.

## Resources

| Resource |
| --- |
| Corporate management |
| Project Office coordinator |
| Analyst |
| Developer |
| Project Office staff analyst |

## Schedule

| ID | WBS | Task | Type | Duration | Start | Finish | Predecessors | Total slack | Resources | Work |
| --- | --- | --- | --- | --- | --- | --- | --- | --- | --- | --- |
| 1 | 1 | **Project Office Template** |  | 150d | 2006-06-01 | 2006-12-27 |  | 0d |  | 1836h |
| 2 | 1.1 | **Scope** |  | 15d | 2006-06-01 | 2006-06-21 |  | 0d |  | 240h |
| 3 | 1.1.1 | Document high-level Project Office requirements including resources |  | 10d | 2006-06-01 | 2006-06-14 |  | 0d | Corporate management; Project Office coordinator | 160h |
| 4 | 1.1.2 | Secure executive sponsorship |  | 2d | 2006-06-15 | 2006-06-16 | 3 | 0d | Corporate management; Project Office coordinator | 32h |
| 5 | 1.1.3 | Determine Project Office scope |  | 3d | 2006-06-19 | 2006-06-21 | 4 | 0d | Corporate management; Project Office coordinator | 48h |
| 6 | 1.1.4 | Approval/Scope complete | milestone | 0d | 2006-06-21 | 2006-06-21 | 5 | 0d |  |  |
| 7 | 1.2 | **Planning** |  | 54.5d | 2006-06-22 | 2006-09-06 |  | 0d |  | 696h |
| 8 | 1.2.1 | **Analysis/Logistics** |  | 15d | 2006-06-22 | 2006-07-12 |  | 0d |  | 144h |
| 9 | 1.2.1.1 | Review Project Office scope documentation |  | 1d | 2006-06-22 | 2006-06-22 | 6 | 0d | Project Office coordinator | 8h |
| 10 | 1.2.1.2 | Establish a management framework (Governance) |  | 3d | 2006-06-23 | 2006-06-27 | 9 | 0d | Corporate management; Project Office coordinator | 48h |
| 11 | 1.2.1.3 | Define mission statement |  | 2d | 2006-06-28 | 2006-06-29 | 10 | 0d | Project Office coordinator | 16h |
| 12 | 1.2.1.4 | Define goals |  | 3d | 2006-06-30 | 2006-07-04 | 11 | 0d | Project Office coordinator | 24h |
| 13 | 1.2.1.5 | Establish communications plan |  | 1d | 2006-07-05 | 2006-07-05 | 12 | 0d | Project Office coordinator | 8h |
| 14 | 1.2.1.6 | Secure Project Office core resources |  | 1w | 2006-07-06 | 2006-07-12 | 13 | 0d | Project Office coordinator | 40h |
| 15 | 1.2.1.7 | Approval/ Logistics complete | milestone | 0d | 2006-07-12 | 2006-07-12 | 14 | 0d |  |  |
| 16 | 1.2.2 | **Policies and Procedures** |  | 15d | 2006-07-13 | 2006-08-02 |  | 0d |  | 240h |
| 17 | 1.2.2.1 | Define Project Office priorities |  | 1w | 2006-07-13 | 2006-07-19 | 15 | 0d | Project Office coordinator; Analyst | 80h |
| 18 | 1.2.2.2 | Define "best of breed" processes, tools and techniques |  | 1w | 2006-07-20 | 2006-07-26 | 14, 17 | 0d | Project Office coordinator; Analyst | 80h |
| 19 | 1.2.2.3 | Define reporting requirements |  | 1w | 2006-07-27 | 2006-08-02 | 18 | 0d | Project Office coordinator; Analyst | 80h |
| 20 | 1.2.2.4 | Approval/ Policies and procedures complete | milestone | 0d | 2006-08-02 | 2006-08-02 | 19 | 0d |  |  |
| 21 | 1.2.3 | **Project Standards and Controls** |  | 23d | 2006-08-03 | 2006-09-04 |  | 0d |  | 288h |
| 22 | 1.2.3.1 | Define security/roles/responsibilities |  | 3d | 2006-08-03 | 2006-08-07 | 20 | 0d | Project Office coordinator; Analyst | 48h |
| 23 | 1.2.3.2 | Create project numbering schema |  | 2d | 2006-08-08 | 2006-08-09 | 22 | 0d | Project Office coordinator; Analyst | 32h |
| 24 | 1.2.3.3 | Define financial reporting integration |  | 1w | 2006-08-10 | 2006-08-16 | 23 | 0d | Project Office coordinator; Analyst | 80h |
| 25 | 1.2.3.4 | Identify project categories for template creation |  | 3d | 2006-08-17 | 2006-08-21 | 24 | 0d | Project Office coordinator; Analyst | 48h |
| 26 | 1.2.3.5 | Create project templates |  | 2w | 2006-08-22 | 2006-09-04 | 25 | 0d | Developer | 80h |
| 27 | 1.2.3.6 | Approve/ Project standards and controls complete | milestone | 0d | 2006-09-04 | 2006-09-04 | 26 | 0d |  |  |
| 28 | 1.2.4 | Empower Project Office |  | 1d | 2006-09-05 | 2006-09-05 | 27 | 0d | Corporate management; Project Office coordinator | 16h |
| 29 | 1.2.5 | Announce Project Office |  | 4h | 2006-09-06 | 2006-09-06 | 28 | 0d | Corporate management; Project Office coordinator | 8h |
| 30 | 1.2.6 | Planning complete | milestone | 0d | 2006-09-06 | 2006-09-06 | 29 | 0d |  |  |

| ID | WBS | Task | Type | Duration | Start | Finish | Predecessors | Total slack | Free slack | Resources | Work |
| --- | --- | --- | --- | --- | --- | --- | --- | --- | --- | --- | --- |
| 31 | 1.3 | **Initiate Project Office** |  | 32d | 2006-09-06 | 2006-10-20 |  | 0d |  |  | 400h |
| 32 | 1.3.1 | Staff Project Office personnel |  | 1w | 2006-09-06 | 2006-09-13 | 30 | 0d |  | Project Office coordinator | 40h |
| 33 | 1.3.2 | **Project Office Support for Existing Projects** |  | 11d | 2006-09-13 | 2006-09-28 |  | 16d |  |  | 104h |
| 34 | 1.3.2.1 | Determine existing projects for Project Office |  | 2d | 2006-09-13 | 2006-09-15 | 32 | 16d | 0d | Project Office coordinator; Project Office staff analyst | 32h |
| 35 | 1.3.2.2 | Audit projects |  | 1w | 2006-09-15 | 2006-09-22 | 34 | 16d | 0d | Project Office staff analyst | 40h |
| 36 | 1.3.2.3 | Modify projects for compliance |  | 3d | 2006-09-22 | 2006-09-27 | 35 | 16d | 0d | Project Office staff analyst | 24h |
| 37 | 1.3.2.4 | Enter projects into Project Office management system |  | 1d | 2006-09-27 | 2006-09-28 | 36 | 16d | 0d | Project Office staff analyst | 8h |
| 38 | 1.3.2.5 | Project Office support for existing projects complete | milestone | 0d | 2006-09-28 | 2006-09-28 | 37 | 16d |  |  |  |
| 39 | 1.3.3 | **Project Office Support for New Projects** |  | 27d | 2006-09-13 | 2006-10-20 |  | 0d |  |  | 256h |
| 40 | 1.3.3.1 | Identify new projects for Project Office |  | 1w | 2006-09-13 | 2006-09-20 | 32 | 0d |  | Project Office coordinator; Project Office staff analyst | 80h |
| 41 | 1.3.3.2 | Create project using Project Office criteria/templates |  | 2w | 2006-09-20 | 2006-10-04 | 40 | 0d |  | Project Office staff analyst | 80h |
| 42 | 1.3.3.3 | Establish monitoring criteria |  | 3d | 2006-10-04 | 2006-10-09 | 41 | 0d |  | Project Office staff analyst | 24h |
| 43 | 1.3.3.4 | Establish performance metrics |  | 4d | 2006-10-09 | 2006-10-13 | 42 | 0d |  | Project Office staff analyst | 32h |
| 44 | 1.3.3.5 | Establish budget guidelines |  | 3d | 2006-10-13 | 2006-10-18 | 43 | 0d |  | Project Office staff analyst | 24h |
| 45 | 1.3.3.6 | Enter project into Project Office management system |  | 2d | 2006-10-18 | 2006-10-20 | 44 | 0d |  | Project Office staff analyst | 16h |
| 46 | 1.3.3.7 | Project Office support for new projects complete | milestone | 0d | 2006-10-20 | 2006-10-20 | 45 | 0d |  |  |  |
| 47 | 1.3.4 | Initiate Project Office complete | milestone | 0d | 2006-10-20 | 2006-10-20 | 46, 38 | 0d |  |  |  |
| 48 | 1.4 | **Management (ongoing)** |  | 29.5d | 2006-10-20 | 2006-11-30 |  | 0d |  |  | 236h |
| 49 | 1.4.1 | Review business priorities applicable to projects |  | 1w | 2006-10-20 | 2006-10-27 | 47 | 0d |  | Project Office staff analyst | 40h |
| 50 | 1.4.2 | **Risk Assessment** |  | 13d | 2006-10-27 | 2006-11-15 |  | 0d |  |  | 104h |
| 51 | 1.4.2.1 | Perform risk assessment |  | 1w | 2006-10-27 | 2006-11-03 | 49 | 0d |  | Project Office staff analyst | 40h |
| 52 | 1.4.2.2 | Evaluate risk assessment against project priorities |  | 3d | 2006-11-03 | 2006-11-08 | 51 | 0d |  | Project Office staff analyst | 24h |
| 53 | 1.4.2.3 | Prepare contingency plans |  | 1w | 2006-11-08 | 2006-11-15 | 52 | 0d |  | Project Office staff analyst | 40h |
| 54 | 1.4.2.4 | Risk assessment complete | milestone | 0d | 2006-11-15 | 2006-11-15 | 53 | 0d |  |  |  |

| ID | WBS | Task | Type | Duration | Start | Finish | Predecessors | Total slack | Resources | Work |
| --- | --- | --- | --- | --- | --- | --- | --- | --- | --- | --- |
| 55 | 1.4.3 | **Monitoring** |  | 11.5d | 2006-11-15 | 2006-11-30 |  | 0d |  | 92h |
| 56 | 1.4.3.1 | Prepare project review meeting agenda (ongoing) |  | 1d | 2006-11-15 | 2006-11-16 | 54 | 0d | Project Office staff analyst | 8h |
| 57 | 1.4.3.2 | Conduct project review meetings (ongoing) |  | 4h | 2006-11-16 | 2006-11-16 | 56 | 0d | Project Office staff analyst | 4h |
| 58 | 1.4.3.3 | Create reports for critical issues, budgets, allocating resources, tracking progress, etc. |  | 2d | 2006-11-17 | 2006-11-20 | 57 | 0d | Project Office staff analyst | 16h |
| 59 | 1.4.3.4 | Mitigate critical issues |  | 2d | 2006-11-21 | 2006-11-22 | 58 | 0d | Project Office staff analyst | 16h |
| 60 | 1.4.3.5 | Allocate resources |  | 2d | 2006-11-23 | 2006-11-24 | 59 | 0d | Project Office staff analyst | 16h |
| 61 | 1.4.3.6 | Freeze/release project baselines |  | 2d | 2006-11-27 | 2006-11-28 | 60 | 0d | Project Office staff analyst | 16h |
| 62 | 1.4.3.7 | Establish change management control |  | 1d | 2006-11-29 | 2006-11-29 | 61 | 0d | Project Office staff analyst | 8h |
| 63 | 1.4.3.8 | Freeze/release project budgets |  | 1d | 2006-11-30 | 2006-11-30 | 62 | 0d | Project Office staff analyst | 8h |
| 64 | 1.4.3.9 | Monitoring complete | milestone | 0d | 2006-11-30 | 2006-11-30 | 63 | 0d |  |  |
| 65 | 1.5 | **Historical/Archival** |  | 8d | 2006-12-01 | 2006-12-12 |  | 0d |  | 88h |
| 66 | 1.5.1 | Establish project archives |  | 3d | 2006-12-01 | 2006-12-05 | 64 | 0d | Project Office coordinator; Project Office staff analyst | 48h |
| 67 | 1.5.2 | Establish lessons learned repository |  | 3d | 2006-12-06 | 2006-12-08 | 66 | 0d | Project Office staff analyst | 24h |
| 68 | 1.5.3 | Manage project archives |  | 2d | 2006-12-11 | 2006-12-12 | 67 | 0d | Project Office staff analyst | 16h |
| 69 | 1.5.4 | Historical complete | milestone | 0d | 2006-12-12 | 2006-12-12 | 68 | 0d |  |  |
| 70 | 1.6 | **Post Implementation Review** |  | 11d | 2006-12-13 | 2006-12-27 |  | 0d |  | 176h |
| 71 | 1.6.1 | Obtain user feedback |  | 3d | 2006-12-13 | 2006-12-15 | 69 | 0d | Project Office coordinator; Project Office staff analyst | 48h |
| 72 | 1.6.2 | Evaluate lessons learned |  | 1w | 2006-12-18 | 2006-12-22 | 71 | 0d | Project Office coordinator; Project Office staff analyst | 80h |
| 73 | 1.6.3 | Modify Items as necessary |  | 3d | 2006-12-25 | 2006-12-27 | 72 | 0d | Project Office coordinator; Project Office staff analyst | 48h |
| 74 | 1.6.4 | Final Approval/ Post implementation review complete | milestone | 0d | 2006-12-27 | 2006-12-27 | 73 | 0d |  |  |
| 75 | 1.7 | Project Office template complete | milestone | 0d | 2006-12-27 | 2006-12-27 | 74 | 0d |  |  |
